# Cronograma proceso

Schedule from MS Project, 2022-01-03 to 2022-06-10, costs in $.

## Calendars

- Estándar: Mon-Fri 09:00-13:00, 15:00-19:00; Sat-Sun off.

## Resources

| Resource | Group | Unit | Rate |
| --- | --- | --- | --- |
| Gerentes de Proyecto 1 | Mano de Obra |  | 406160 |
| Gerentes de Procesos | Mano de Obra |  | 406160 |
| Pofecional civil exp banco | Mano de Obra |  | 213234 |
| Pofecional civil exp banco 2 | Mano de Obra |  | 213234 |
| Pofecional Ing electrico | Mano de Obra |  | 213234 |
| Pofecional Ing mecanico | Mano de Obra |  | 213234 |
| Sillas escritorio | Equipos | Unidad | 600000 |
| Puestos de trabajo o escritorios en madera pequeños | Equipos | Unidad | 800000 |
| Puestos de trabajo o escritorios en madera grandes | Equipos | Unidad | 1500000 |
| Sillas interlocutoras escritorios | Equipos | Unidad | 350000 |
| Mueble en madera(documentos) | Equipos | Unidad | 800000 |
| Muebles impresoras | Equipos | Unidad | 1000000 |
| Impresora | Equipos | Unidad | 1000000 |
| Computadores portatiles | Equipos | Unidad | 4500000 |
| Proyector | Equipos | Unidad | 3500000 |
| Celulares | Equipos | Unidad | 5000000 |
| Agua | Gasto | Gasto | 40000 |
| Luz | Gasto | Gasto | 40000 |
| Plan de Telefono | Gasto | Gasto | 50000 |

## Schedule

| ID | WBS | Task | Duration | Start | Finish | Predecessors | Baseline start | Baseline finish | Baseline duration | Total slack | Resources | Work | Cost | Baseline cost |
| --- | --- | --- | --- | --- | --- | --- | --- | --- | --- | --- | --- | --- | --- | --- |
| 1 | 1 | **1. Análisis de una solución para la supervisión y control de obra del área de proyectos en una entidad bancaria mixta** | 114.25d? | 2022-01-03 09:00 | 2022-06-10 11:00 |  | 2022-01-03 09:00 | 2022-06-10 11:00 | 114.25d? | 0d |  | 1759h | 1,064,933,872 | 1,064,933,872 |
| 3 | 1.1 | Inicio | 1d? | 2022-01-03 09:00 | 2022-01-03 19:00 |  | 2022-01-03 09:00 | 2022-01-03 19:00 | 1d? | 0d |  |  |  |  |
| 4 | 1.2 | **1.1. ANALISIS** | 40.75d? | 2022-01-04 09:00 | 2022-03-01 17:00 | 3 | 2022-01-04 09:00 | 2022-03-01 17:00 | 40.75d? | 0d |  | 404h | 213,504,784 | 213,504,784 |
| 5 | 1.2.1 | 1.1.1. Infome estado actual del proceso | 2d | 2022-01-04 09:00 | 2022-01-05 19:00 | 3 | 2022-01-04 09:00 | 2022-01-05 19:00 | 2d | 0d | Gerentes de Procesos [50%]; Gerentes de Proyecto 1 [50%]; Computadores portatiles [1 Unidad]; Luz [1 Gasto]; Celulares [1 Unidad]; Sillas escritorio [1 Unidad] | 16h | 16,638,560 | 16,638,560 |
| 6 | 1.2.2 | Reunion seguimiento | 0.12d | 2022-01-06 09:00 | 2022-01-06 10:00 | 5 | 2022-01-06 09:00 | 2022-01-06 10:00 | 0.12d | 0d | Gerentes de Procesos; Gerentes de Proyecto 1 | 2h | 812,320 | 812,320 |
| 7 | 1.2.3 | **1.1.1.1. Informe levantamiento de la informacion** | 14.38d | 2022-01-06 10:00 | 2022-01-26 13:00 |  | 2022-01-06 10:00 | 2022-01-26 13:00 | 14.38d | 0d |  | 134h | 69,591,808 | 69,591,808 |
| 8 | 1.2.3.1 | 1.1.1.1.1. REUNIÓN CON DIRECTOR DE PLANEACIÓN | 4d | 2022-01-06 10:00 | 2022-01-12 10:00 | 6 | 2022-01-06 10:00 | 2022-01-12 10:00 | 4d | 0d | Gerentes de Procesos [50%]; Gerentes de Proyecto 1 [50%]; Pofecional civil exp banco [25%]; Pofecional civil exp banco 2 [25%]; Pofecional Ing electrico [25%]; Pofecional Ing mecanico [25%]; Computadores portatiles [1 Unidad]; Sillas interlocutoras escritorios [1 Unidad]; Sillas escritorio [1 Unidad]; Proyector [1 Unidad]; Plan de Telefono [1 Gasto] | 48h | 22,322,048 | 22,322,048 |
| 9 | 1.2.3.2 | Reunion seguimiento | 0.12d | 2022-01-12 10:00 | 2022-01-12 11:00 | 8 | 2022-01-12 10:00 | 2022-01-12 11:00 | 0.12d | 0d | Gerentes de Procesos; Gerentes de Proyecto 1 | 2h | 812,320 | 812,320 |
| 10 | 1.2.3.3 | 1.1.1.1.2. REALIZACIÓN DE DOCUMENTO CON LEVANTAMIENTO DE REQUERIMIENTOS | 8d | 2022-01-12 11:00 | 2022-01-24 11:00 | 9 | 2022-01-12 11:00 | 2022-01-24 11:00 | 8d | 0d | Celulares [1 Unidad]; Computadores portatiles [1 Unidad]; Mueble en madera(documentos) [1 Unidad]; Muebles impresoras [1 Unidad]; Impresora [1 Unidad]; Luz [1 Gasto]; Gerentes de Procesos [50%]; Gerentes de Proyecto 1 [50%] | 64h | 38,334,240 | 38,334,240 |
| 11 | 1.2.3.4 | Reunion seguimiento | 0.12d | 2022-01-24 11:00 | 2022-01-24 12:00 | 10 | 2022-01-24 11:00 | 2022-01-24 12:00 | 0.12d | 0d | Gerentes de Procesos; Gerentes de Proyecto 1 | 2h | 812,320 | 812,320 |
| 12 | 1.2.3.5 | 1.1.1.1.3. REUNIÓN DE APROBACIÓN | 2d | 2022-01-24 12:00 | 2022-01-26 12:00 | 11 | 2022-01-24 12:00 | 2022-01-26 12:00 | 2d | 0d | Gerentes de Procesos [50%]; Gerentes de Proyecto 1 [50%] | 16h | 6,498,560 | 6,498,560 |
| 13 | 1.2.3.6 | Reunion seguimiento | 0.12d | 2022-01-26 12:00 | 2022-01-26 13:00 | 12 | 2022-01-26 12:00 | 2022-01-26 13:00 | 0.12d | 0d | Gerentes de Procesos; Gerentes de Proyecto 1 | 2h | 812,320 | 812,320 |
| 14 | 1.2.4 | **1.1.1.2. Formatos de encuetas de area** | 7.38d | 2022-01-26 15:00 | 2022-02-04 18:00 |  | 2022-01-26 15:00 | 2022-02-04 18:00 | 7.38d | 0d |  | 110h | 59,627,376 | 59,627,376 |
| 15 | 1.2.4.1 | 1.1.1.2.1.REALIZACIÓN DE ENCUESTA | 3d | 2022-01-26 15:00 | 2022-01-31 13:00 | 13 | 2022-01-26 15:00 | 2022-01-31 13:00 | 3d | 0d | Gerentes de Procesos [50%]; Gerentes de Proyecto 1 [50%]; Celulares [1 Unidad]; Pofecional civil exp banco [25%]; Pofecional civil exp banco 2 [25%]; Pofecional Ing electrico [25%]; Pofecional Ing mecanico [25%] | 48h | 19,865,456 | 19,865,456 |
| 16 | 1.2.4.2 | Reunion seguimiento | 0.12d | 2022-01-31 15:00 | 2022-01-31 16:00 | 15 | 2022-01-31 15:00 | 2022-01-31 16:00 | 0.12d | 0d | Gerentes de Procesos; Gerentes de Proyecto 1 | 2h | 812,320 | 812,320 |
| 17 | 1.2.4.3 | 1.1.1.2.2. VERIFICACIÓN DE RESULTADOS | 3d | 2022-01-31 16:00 | 2022-02-03 16:00 | 16 | 2022-01-31 16:00 | 2022-02-03 16:00 | 3d | 0d | Gerentes de Procesos; Gerentes de Proyecto 1; Proyector [1 Unidad]; Celulares [1 Unidad]; Luz [1 Gasto] | 48h | 28,035,680 | 28,035,680 |
| 18 | 1.2.4.4 | Reunion seguimiento | 0.12d | 2022-02-03 16:00 | 2022-02-03 17:00 | 17 | 2022-02-03 16:00 | 2022-02-03 17:00 | 0.12d | 0d | Gerentes de Procesos; Gerentes de Proyecto 1 | 2h | 812,320 | 812,320 |
| 19 | 1.2.4.5 | 1.1.1.2.3. INFORME | 1d | 2022-02-03 17:00 | 2022-02-04 17:00 | 18 | 2022-02-03 17:00 | 2022-02-04 17:00 | 1d | 0d | Luz [1 Gasto]; Impresora [1 Unidad]; Gerentes de Procesos [50%]; Gerentes de Proyecto 1 [50%]; Celulares [1 Unidad] | 8h | 9,289,280 | 9,289,280 |
| 20 | 1.2.4.6 | Reunion seguimiento | 0.12d | 2022-02-04 17:00 | 2022-02-04 18:00 | 19 | 2022-02-04 17:00 | 2022-02-04 18:00 | 0.12d | 0d | Gerentes de Procesos; Gerentes de Proyecto 1 | 2h | 812,320 | 812,320 |
| 21 | 1.2.5 | **1.1.1.3. Analisis de la informacion de datos** | 5.38d | 2022-02-04 18:00 | 2022-02-14 11:00 |  | 2022-02-04 18:00 | 2022-02-14 11:00 | 5.38d | 0d |  | 46h | 27,803,360 | 27,803,360 |
| 22 | 1.2.5.1 | 1.1.1.3.1. ANALISIS DE LA INFORMACIÓN | 1d | 2022-02-04 18:00 | 2022-02-07 18:00 | 20 | 2022-02-04 18:00 | 2022-02-07 18:00 | 1d | 0d | Computadores portatiles [1 Unidad]; Gerentes de Procesos [50%]; Gerentes de Proyecto 1 [50%]; Luz [1 Gasto] | 8h | 7,789,280 | 7,789,280 |
| 23 | 1.2.5.2 | Reunion seguimiento | 0.12d | 2022-02-07 18:00 | 2022-02-07 19:00 | 22 | 2022-02-07 18:00 | 2022-02-07 19:00 | 0.12d | 0d | Gerentes de Procesos; Gerentes de Proyecto 1 | 2h | 812,320 | 812,320 |
| 24 | 1.2.5.3 | 1.1.1.3.2. ELAVORACION DE INFORME | 3d | 2022-02-08 09:00 | 2022-02-10 19:00 | 23 | 2022-02-08 09:00 | 2022-02-10 19:00 | 3d | 0d | Computadores portatiles [1 Unidad]; Gerentes de Procesos [50%]; Gerentes de Proyecto 1 [50%]; Luz [1 Gasto] | 24h | 14,287,840 | 14,287,840 |
| 25 | 1.2.5.4 | Reunion seguimiento | 0.12d | 2022-02-11 09:00 | 2022-02-11 10:00 | 24 | 2022-02-11 09:00 | 2022-02-11 10:00 | 0.12d | 0d | Gerentes de Procesos; Gerentes de Proyecto 1 | 2h | 812,320 | 812,320 |
| 26 | 1.2.5.5 | 1.1.1.3.3. INFORME | 1d | 2022-02-11 10:00 | 2022-02-14 10:00 | 25 | 2022-02-11 10:00 | 2022-02-14 10:00 | 1d | 0d | Gerentes de Procesos [50%]; Gerentes de Proyecto 1 [50%]; Luz [1 Gasto] | 8h | 3,289,280 | 3,289,280 |
| 27 | 1.2.5.6 | Reunion seguimiento | 0.12d | 2022-02-14 10:00 | 2022-02-14 11:00 | 26 | 2022-02-14 10:00 | 2022-02-14 11:00 | 0.12d | 0d | Gerentes de Procesos; Gerentes de Proyecto 1 | 2h | 812,320 | 812,320 |

| ID | WBS | Task | Type | Duration | Start | Finish | Predecessors | Baseline start | Baseline finish | Baseline duration | Total slack | Resources | Work | Cost | Baseline cost |
| --- | --- | --- | --- | --- | --- | --- | --- | --- | --- | --- | --- | --- | --- | --- | --- |
| 28 | 1.2.6 | **1.1.2. Infome de alternativas** |  | 11.5d? | 2022-02-14 11:00 | 2022-03-01 17:00 |  | 2022-02-14 11:00 | 2022-03-01 17:00 | 11.5d? | 0d |  | 96h | 39,031,360 | 39,031,360 |
| 29 | 1.2.6.1 | **1.1.2.1. Analisis de las alternativas** |  | 7.25d | 2022-02-14 11:00 | 2022-02-23 13:00 |  | 2022-02-14 11:00 | 2022-02-23 13:00 | 7.25d | 0d |  | 60h | 24,409,600 | 24,409,600 |
| 30 | 1.2.6.1.1 | 1.1.2.1.1 ANALISIS ALTERNATIVAS |  | 4d | 2022-02-14 11:00 | 2022-02-18 11:00 | 27 | 2022-02-14 11:00 | 2022-02-18 11:00 | 4d | 0d | Gerentes de Procesos [50%]; Gerentes de Proyecto 1 [50%]; Luz [1 Gasto] | 32h | 13,037,120 | 13,037,120 |
| 31 | 1.2.6.1.2 | Reunion seguimiento |  | 0.12d | 2022-02-18 11:00 | 2022-02-18 12:00 | 30 | 2022-02-18 11:00 | 2022-02-18 12:00 | 0.12d | 0d | Gerentes de Procesos; Gerentes de Proyecto 1 | 2h | 812,320 | 812,320 |
| 32 | 1.2.6.1.3 | 1.1.2.1.2. INFORME DE ALTERNATIVAS |  | 3d | 2022-02-18 12:00 | 2022-02-23 12:00 | 31 | 2022-02-18 12:00 | 2022-02-23 12:00 | 3d | 0d | Gerentes de Procesos [50%]; Gerentes de Proyecto 1 [50%] | 24h | 9,747,840 | 9,747,840 |
| 33 | 1.2.6.1.4 | Reunion seguimiento |  | 0.12d | 2022-02-23 12:00 | 2022-02-23 13:00 | 32 | 2022-02-23 12:00 | 2022-02-23 13:00 | 0.12d | 0d | Gerentes de Procesos; Gerentes de Proyecto 1 | 2h | 812,320 | 812,320 |
| 34 | 1.2.6.2 | **1.1.2.2. Seleccion de la alternativa** |  | 4.25d? | 2022-02-23 15:00 | 2022-03-01 17:00 |  | 2022-02-23 15:00 | 2022-03-01 17:00 | 4.25d? | 0d |  | 36h | 14,621,760 | 14,621,760 |
| 35 | 1.2.6.2.1 | 1.1.2.2.1. VALIDACION DE LAS ALTERNTIVAS |  | 3d | 2022-02-23 15:00 | 2022-02-28 13:00 | 33 | 2022-02-23 15:00 | 2022-02-28 13:00 | 3d | 0d | Gerentes de Procesos [50%]; Gerentes de Proyecto 1 [50%] | 24h | 9,747,840 | 9,747,840 |
| 36 | 1.2.6.2.2 | Reunion seguimiento |  | 0.12d | 2022-02-28 15:00 | 2022-02-28 16:00 | 35 | 2022-02-28 15:00 | 2022-02-28 16:00 | 0.12d | 0d | Gerentes de Procesos; Gerentes de Proyecto 1 | 2h | 812,320 | 812,320 |
| 37 | 1.2.6.2.3 | 1.1.2.2.2. INFORME DE ALTERNATIVA SELECCIONADA |  | 1d | 2022-02-28 16:00 | 2022-03-01 16:00 | 36 | 2022-02-28 16:00 | 2022-03-01 16:00 | 1d | 0d | Gerentes de Procesos [50%]; Gerentes de Proyecto 1 [50%] | 8h | 3,249,280 | 3,249,280 |
| 38 | 1.2.6.2.4 | Reunion seguimiento |  | 0.12d? | 2022-03-01 16:00 | 2022-03-01 17:00 | 37 | 2022-03-01 16:00 | 2022-03-01 17:00 | 0.12d? | 0d | Gerentes de Procesos; Gerentes de Proyecto 1 | 2h | 812,320 | 812,320 |
| 39 | 1.3 | FASE DE ANALISIS TERMINADA | milestone | 0d | 2022-03-01 17:00 | 2022-03-01 17:00 | 38 | 2022-03-01 17:00 | 2022-03-01 17:00 | 0d | 0d |  |  |  |  |
| 40 | 1.4 | **1.2. Diseño** |  | 5.38d? | 2022-03-01 17:00 | 2022-03-09 10:00 |  | 2022-03-01 17:00 | 2022-03-09 10:00 | 5.38d? | 0d |  | 46h | 36,763,360 | 36,763,360 |
| 41 | 1.4.1 | **1.2.1. Diseño de alternativa** |  | 4.25d | 2022-03-01 17:00 | 2022-03-07 19:00 |  | 2022-03-01 17:00 | 2022-03-07 19:00 | 4.25d | 0d |  | 36h | 24,701,760 | 24,701,760 |
| 42 | 1.4.1.1 | 1.2.1.1. VALIDACION DE DISEÑO |  | 3d | 2022-03-01 17:00 | 2022-03-04 17:00 | 39 | 2022-03-01 17:00 | 2022-03-04 17:00 | 3d | 0d | Gerentes de Procesos [50%]; Gerentes de Proyecto 1 [50%]; Computadores portatiles [1 Unidad]; Luz [1 Gasto] | 24h | 14,287,840 | 14,287,840 |
| 43 | 1.4.1.2 | Reunion seguimiento |  | 0.12d | 2022-03-04 17:00 | 2022-03-04 18:00 | 42 | 2022-03-04 17:00 | 2022-03-04 18:00 | 0.12d | 0d | Gerentes de Procesos; Gerentes de Proyecto 1 | 2h | 812,320 | 812,320 |
| 44 | 1.4.1.3 | 1.2.1.2. INFOME DE DISEÑOS DE HERRMIENTAS |  | 1d | 2022-03-04 18:00 | 2022-03-07 18:00 | 43 | 2022-03-04 18:00 | 2022-03-07 18:00 | 1d | 0d | Computadores portatiles [1 Unidad]; Gerentes de Proyecto 1 [50%]; Gerentes de Procesos [50%]; Luz [1 Gasto]; Impresora [1 Unidad] | 8h | 8,789,280 | 8,789,280 |
| 45 | 1.4.1.4 | Reunion seguimiento |  | 0.12d | 2022-03-07 18:00 | 2022-03-07 19:00 | 44 | 2022-03-07 18:00 | 2022-03-07 19:00 | 0.12d | 0d | Gerentes de Procesos; Gerentes de Proyecto 1 | 2h | 812,320 | 812,320 |
| 46 | 1.4.2 | **1.2.2. Diseños de Formato de Aprobación** |  | 1.12d? | 2022-03-08 09:00 | 2022-03-09 10:00 |  | 2022-03-08 09:00 | 2022-03-09 10:00 | 1.12d? | 0d |  | 10h | 12,061,600 | 12,061,600 |
| 47 | 1.4.2.1 | 1.2.2.1. PRESENTACION DE FORMATOS DE DISEÑO |  | 1d | 2022-03-08 09:00 | 2022-03-08 19:00 | 45 | 2022-03-08 09:00 | 2022-03-08 19:00 | 1d | 0d | Gerentes de Procesos [50%]; Gerentes de Proyecto 1 [50%]; Computadores portatiles [1 Unidad]; Proyector [1 Unidad] | 8h | 11,249,280 | 11,249,280 |
| 48 | 1.4.2.2 | Reunion seguimiento |  | 0.12d? | 2022-03-09 09:00 | 2022-03-09 10:00 | 47 | 2022-03-09 09:00 | 2022-03-09 10:00 | 0.12d? | 0d | Gerentes de Procesos; Gerentes de Proyecto 1 | 2h | 812,320 | 812,320 |
| 49 | 1.5 | FACE DE DISEÑO TERMINADO | milestone | 0d | 2022-03-09 10:00 | 2022-03-09 10:00 | 48 | 2022-03-09 10:00 | 2022-03-09 10:00 | 0d | 0d |  |  |  |  |
| 50 | 1.6 | **1.3. Construcción** |  | 18.25d | 2022-03-09 10:00 | 2022-04-04 12:00 |  | 2022-03-09 10:00 | 2022-04-04 12:00 | 18.25d | 0d |  | 148h | 68,191,680 | 68,191,680 |
| 51 | 1.6.1 | **1.3.1. Formatos de proceso** |  | 8.12d | 2022-03-09 10:00 | 2022-03-21 11:00 |  | 2022-03-09 10:00 | 2022-03-21 11:00 | 8.12d | 0d |  | 66h | 33,846,560 | 33,846,560 |
| 52 | 1.6.1.1 | 1.3.1.1. CRECION DE FORMATOS DISEÑADOS |  | 8d | 2022-03-09 10:00 | 2022-03-21 10:00 | 49 | 2022-03-09 10:00 | 2022-03-21 10:00 | 8d | 0d | Computadores portatiles [1 Unidad]; Gerentes de Procesos [50%]; Gerentes de Proyecto 1 [50%]; Impresora [1 Unidad]; Luz [1 Gasto]; Puestos de trabajo o escritorios en madera grandes [1 Unidad] | 64h | 33,034,240 | 33,034,240 |
| 53 | 1.6.1.2 | Reunion seguimiento |  | 0.12d | 2022-03-21 10:00 | 2022-03-21 11:00 | 52 | 2022-03-21 10:00 | 2022-03-21 11:00 | 0.12d | 0d | Gerentes de Procesos; Gerentes de Proyecto 1 | 2h | 812,320 | 812,320 |

| ID | WBS | Task | Type | Duration | Start | Finish | Predecessors | Baseline start | Baseline finish | Baseline duration | Total slack | Resources | Work | Cost | Baseline cost |
| --- | --- | --- | --- | --- | --- | --- | --- | --- | --- | --- | --- | --- | --- | --- | --- |
| 54 | 1.6.2 | **1.3.2. Aprobación de formatos** |  | 10.12d | 2022-03-21 11:00 | 2022-04-04 12:00 |  | 2022-03-21 11:00 | 2022-04-04 12:00 | 10.12d | 0d |  | 82h | 34,345,120 | 34,345,120 |
| 55 | 1.6.2.1 | 1.3.2.1. INFORME DE FORMATOS CREADOS |  | 10d | 2022-03-21 11:00 | 2022-04-04 11:00 | 53 | 2022-03-21 11:00 | 2022-04-04 11:00 | 10d | 0d | Gerentes de Procesos [50%]; Gerentes de Proyecto 1 [50%]; Luz [1 Gasto]; Impresora [1 Unidad] | 80h | 33,532,800 | 33,532,800 |
| 56 | 1.6.2.2 | Reunion seguimiento |  | 0.12d | 2022-04-04 11:00 | 2022-04-04 12:00 | 55 | 2022-04-04 11:00 | 2022-04-04 12:00 | 0.12d | 0d | Gerentes de Procesos; Gerentes de Proyecto 1 | 2h | 812,320 | 812,320 |
| 57 | 1.7 | FACE DE COSTRUCCION TERMINADO | milestone | 0d | 2022-04-04 12:00 | 2022-04-04 12:00 | 56 | 2022-04-04 12:00 | 2022-04-04 12:00 | 0d | 0d |  |  |  |  |
| 58 | 1.8 | **1.4. Implementación** |  | 10.75d | 2022-04-04 12:00 | 2022-04-19 10:00 |  | 2022-04-04 12:00 | 2022-04-19 10:00 | 10.75d | 0d |  | 183h | 110,948,088 | 110,948,088 |
| 59 | 1.8.1 | **1.4.1. Solución de proceso** |  | 2.12d | 2022-04-04 12:00 | 2022-04-06 13:00 |  | 2022-04-04 12:00 | 2022-04-06 13:00 | 2.12d | 0d |  | 18h | 8,350,880 | 8,350,880 |
| 60 | 1.8.1.1 | 1.4.1.1. INFOME DE LA MEJORA DEL PROCESO |  | 2d | 2022-04-04 12:00 | 2022-04-06 12:00 | 57 | 2022-04-04 12:00 | 2022-04-06 12:00 | 2d | 0d | Gerentes de Procesos [50%]; Gerentes de Proyecto 1 [50%]; Luz [1 Gasto]; Impresora [1 Unidad] | 16h | 7,538,560 | 7,538,560 |
| 61 | 1.8.1.2 | Reunion seguimiento |  | 0.12d | 2022-04-06 12:00 | 2022-04-06 13:00 | 60 | 2022-04-06 12:00 | 2022-04-06 13:00 | 0.12d | 0d | Gerentes de Procesos; Gerentes de Proyecto 1 | 2h | 812,320 | 812,320 |
| 62 | 1.8.2 | **1.4.2. Divulgación de proceso** |  | 7.5d | 2022-04-06 15:00 | 2022-04-15 19:00 |  | 2022-04-06 15:00 | 2022-04-15 19:00 | 7.5d | 0d |  | 151h | 94,726,080 | 94,726,080 |
| 63 | 1.8.2.1 | 1.4.2.1.AGENDAR CAPACITACION |  | 1d | 2022-04-06 15:00 | 2022-04-07 13:00 | 61 | 2022-04-06 15:00 | 2022-04-07 13:00 | 1d | 0d | Celulares [1 Unidad]; Computadores portatiles [1 Unidad]; Gerentes de Procesos [50%]; Gerentes de Proyecto 1 [50%] | 8h | 12,749,280 | 12,749,280 |
| 64 | 1.8.2.2 | Z/ |  | 0.12d | 2022-04-07 15:00 | 2022-04-07 16:00 | 63 | 2022-04-07 15:00 | 2022-04-07 16:00 | 0.12d | 0d | Gerentes de Procesos; Gerentes de Proyecto 1 | 2h | 812,320 | 812,320 |
| 65 | 1.8.2.3 | 1.4.2.2.PRESENTACIÓN CAPACITACION |  | 5d | 2022-04-07 16:00 | 2022-04-14 16:00 | 64 | 2022-04-07 16:00 | 2022-04-14 16:00 | 5d | 0d | Gerentes de Procesos [50%]; Gerentes de Proyecto 1 [50%]; Pofecional civil exp banco [25%]; Pofecional civil exp banco 2 [25%]; Pofecional Ing electrico [25%]; Pofecional Ing mecanico [25%]; Sillas interlocutoras escritorios [1 Unidad]; Luz [1 Gasto]; Proyector [1 Unidad] | 80h | 28,665,760 | 28,665,760 |
| 66 | 1.8.2.4 | capacitacion 1 |  | 0.12d | 2022-04-14 16:00 | 2022-04-14 17:00 | 65 | 2022-04-14 16:00 | 2022-04-14 17:00 | 0.12d | 0d | Gerentes de Procesos; Gerentes de Proyecto 1; Pofecional civil exp banco; Pofecional civil exp banco 2; Pofecional Ing electrico; Pofecional Ing mecanico; Proyector [1 Unidad]; Luz [1 Gasto] | 6h | 5,205,256 | 5,205,256 |
| 67 | 1.8.2.5 | Capacitacion 2 |  | 0.12d | 2022-04-14 17:00 | 2022-04-14 18:00 | 66 | 2022-04-14 17:00 | 2022-04-14 18:00 | 0.12d | 0d | Gerentes de Procesos; Gerentes de Proyecto 1; Pofecional civil exp banco; Pofecional civil exp banco 2; Pofecional Ing electrico; Pofecional Ing mecanico; Proyector [1 Unidad]; Luz [1 Gasto] | 6h | 5,205,256 | 5,205,256 |
| 68 | 1.8.2.6 | Capacitacion 3 |  | 0.12d | 2022-04-14 18:00 | 2022-04-14 19:00 | 67 | 2022-04-14 18:00 | 2022-04-14 19:00 | 0.12d | 0d | Gerentes de Procesos; Gerentes de Proyecto 1; Luz [1 Gasto]; Pofecional civil exp banco; Pofecional civil exp banco 2; Pofecional Ing electrico; Pofecional Ing mecanico; Proyector [1 Unidad] | 6h | 5,205,256 | 5,205,256 |
| 69 | 1.8.2.7 | Capacitacion 4 |  | 0.12d | 2022-04-15 09:00 | 2022-04-15 10:00 | 68 | 2022-04-15 09:00 | 2022-04-15 10:00 | 0.12d | 0d | Gerentes de Procesos; Gerentes de Proyecto 1; Pofecional civil exp banco; Pofecional civil exp banco 2; Pofecional Ing electrico; Pofecional Ing mecanico; Proyector [1 Unidad]; Luz [1 Gasto] | 6h | 5,205,256 | 5,205,256 |
| 70 | 1.8.2.8 | Capacitacion 5 |  | 0.12d | 2022-04-15 10:00 | 2022-04-15 11:00 | 69 | 2022-04-15 10:00 | 2022-04-15 11:00 | 0.12d | 0d | Gerentes de Procesos; Gerentes de Proyecto 1; Pofecional civil exp banco; Pofecional civil exp banco 2; Pofecional Ing electrico; Pofecional Ing mecanico; Proyector [1 Unidad]; Luz [1 Gasto] | 6h | 5,205,256 | 5,205,256 |
| 71 | 1.8.2.9 | Capacitacion 6 |  | 0.12d | 2022-04-15 11:00 | 2022-04-15 12:00 | 70 | 2022-04-15 11:00 | 2022-04-15 12:00 | 0.12d | 0d | Gerentes de Procesos; Gerentes de Proyecto 1; Pofecional civil exp banco; Pofecional civil exp banco 2; Pofecional Ing electrico; Pofecional Ing mecanico; Luz [1 Gasto]; Proyector [1 Unidad] | 6h | 5,205,256 | 5,205,256 |
| 72 | 1.8.2.10 | Capacitacion 7 |  | 0.12d | 2022-04-15 12:00 | 2022-04-15 13:00 | 71 | 2022-04-15 12:00 | 2022-04-15 13:00 | 0.12d | 0d | Agua [1 Gasto]; Gerentes de Proyecto 1; Pofecional civil exp banco; Pofecional civil exp banco 2; Pofecional Ing electrico; Pofecional Ing mecanico; Luz [1 Gasto]; Proyector [1 Unidad] | 5h | 4,839,096 | 4,839,096 |
| 73 | 1.8.2.11 | Capacitacion 8 |  | 0.12d | 2022-04-15 15:00 | 2022-04-15 16:00 | 72 | 2022-04-15 15:00 | 2022-04-15 16:00 | 0.12d | 0d | Gerentes de Procesos; Gerentes de Proyecto 1; Pofecional civil exp banco; Pofecional civil exp banco 2; Pofecional Ing electrico; Pofecional Ing mecanico; Proyector [1 Unidad]; Luz [1 Gasto] | 6h | 5,205,256 | 5,205,256 |
| 74 | 1.8.2.12 | Capacitacion 9 |  | 0.12d | 2022-04-15 16:00 | 2022-04-15 17:00 | 73 | 2022-04-15 16:00 | 2022-04-15 17:00 | 0.12d | 0d | Gerentes de Procesos; Gerentes de Proyecto 1; Pofecional civil exp banco; Pofecional civil exp banco 2; Pofecional Ing electrico; Pofecional Ing mecanico; Luz [1 Gasto]; Proyector [1 Unidad] | 6h | 5,205,256 | 5,205,256 |
| 75 | 1.8.2.13 | Capacitacion 10 |  | 0.12d | 2022-04-15 17:00 | 2022-04-15 18:00 | 74 | 2022-04-15 17:00 | 2022-04-15 18:00 | 0.12d | 0d | Gerentes de Procesos; Gerentes de Proyecto 1; Pofecional civil exp banco; Pofecional civil exp banco 2; Pofecional Ing electrico; Pofecional Ing mecanico; Luz [1 Gasto]; Proyector [1 Unidad] | 6h | 5,205,256 | 5,205,256 |
| 76 | 1.8.2.14 | Reunion seguimiento |  | 0.12d | 2022-04-15 18:00 | 2022-04-15 19:00 | 75 | 2022-04-15 18:00 | 2022-04-15 19:00 | 0.12d | 0d | Gerentes de Procesos; Gerentes de Proyecto 1 | 2h | 812,320 | 812,320 |
| 77 | 1.8.3 | **1.4.3.Validación capacitación** |  | 1.12d | 2022-04-18 09:00 | 2022-04-19 10:00 |  | 2022-04-18 09:00 | 2022-04-19 10:00 | 1.12d | 0d |  | 14h | 7,871,128 | 7,871,128 |
| 78 | 1.8.3.1 | 1.4.3.1. EXAMEN DE PROCESO PRESENTADO |  | 1d | 2022-04-18 09:00 | 2022-04-18 19:00 | 76 | 2022-04-18 09:00 | 2022-04-18 19:00 | 1d | 0d | Pofecional civil exp banco [50%]; Pofecional civil exp banco 2 [50%]; Pofecional Ing electrico [25%]; Pofecional Ing mecanico [25%]; Computadores portatiles [1 Unidad] | 12h | 7,058,808 | 7,058,808 |
| 79 | 1.8.3.2 | Reunion seguimiento |  | 0.12d | 2022-04-19 09:00 | 2022-04-19 10:00 | 78 | 2022-04-19 09:00 | 2022-04-19 10:00 | 0.12d | 0d | Gerentes de Procesos; Gerentes de Proyecto 1 | 2h | 812,320 | 812,320 |
| 80 | 1.9 | FACE DE IMPLEMENTACION TERMINADO | milestone | 0d | 2022-04-19 10:00 | 2022-04-19 10:00 | 79 | 2022-04-19 10:00 | 2022-04-19 10:00 | 0d | 0d |  |  |  |  |

| ID | WBS | Task | Duration | Start | Finish | Predecessors | Baseline start | Baseline finish | Baseline duration | Total slack | Resources | Work | Cost | Baseline cost |
| --- | --- | --- | --- | --- | --- | --- | --- | --- | --- | --- | --- | --- | --- | --- |
| 81 | 1.10 | **1.5 Operación** | 38.12d | 2022-04-19 10:00 | 2022-06-10 11:00 |  | 2022-04-19 10:00 | 2022-06-10 11:00 | 38.12d | 0d |  | 336h | 211,331,240 | 211,331,240 |
| 82 | 1.10.1 | **1.5.1.Gestión del Cambio** | 32.88d | 2022-04-19 10:00 | 2022-06-02 19:00 |  | 2022-04-19 10:00 | 2022-06-02 19:00 | 32.88d | 0d |  | 292h | 174,880,200 | 174,880,200 |
| 83 | 1.10.1.1 | **1.5.1.1.Recolección de la información** | 15.12d | 2022-04-19 10:00 | 2022-05-10 11:00 |  | 2022-04-19 10:00 | 2022-05-10 11:00 | 15.12d | 0d |  | 122h | 54,091,520 | 54,091,520 |
| 84 | 1.10.1.1.1 | 1.5.1.1.1.RECOLECCION Y TABULACION DE PROYECTOS GESTIONADOS | 15d | 2022-04-19 10:00 | 2022-05-10 10:00 | 80 | 2022-04-19 10:00 | 2022-05-10 10:00 | 15d | 0d | Gerentes de Procesos [50%]; Gerentes de Proyecto 1 [50%]; Luz [1 Gasto]; Computadores portatiles [1 Unidad] | 120h | 53,279,200 | 53,279,200 |
| 85 | 1.10.1.1.2 | Reunion seguimiento | 0.12d | 2022-05-10 10:00 | 2022-05-10 11:00 | 84 | 2022-05-10 10:00 | 2022-05-10 11:00 | 0.12d | 0d | Gerentes de Procesos; Gerentes de Proyecto 1 | 2h | 812,320 | 812,320 |
| 86 | 1.10.1.2 | **1.5.1.2.Evaluación de procesos** | 8.25d | 2022-05-10 11:00 | 2022-05-20 13:00 |  | 2022-05-10 11:00 | 2022-05-20 13:00 | 8.25d | 0d |  | 68h | 33,198,880 | 33,198,880 |
| 87 | 1.10.1.2.1 | 1.5.1.2.1.VALIDACION DE PORYECTOS | 5d | 2022-05-10 11:00 | 2022-05-17 11:00 | 85 | 2022-05-10 11:00 | 2022-05-17 11:00 | 5d | 0d | Luz [1 Gasto]; Computadores portatiles [1 Unidad]; Gerentes de Procesos [50%]; Gerentes de Proyecto 1 [50%] | 40h | 20,786,400 | 20,786,400 |
| 88 | 1.10.1.2.2 | Reunion seguimiento | 0.12d | 2022-05-17 11:00 | 2022-05-17 12:00 | 87 | 2022-05-17 11:00 | 2022-05-17 12:00 | 0.12d | 0d | Gerentes de Procesos; Gerentes de Proyecto 1 | 2h | 812,320 | 812,320 |
| 89 | 1.10.1.2.3 | 1.5.1.2.2.INFOME DE PROYECTOS | 3d | 2022-05-17 12:00 | 2022-05-20 12:00 | 88 | 2022-05-17 12:00 | 2022-05-20 12:00 | 3d | 0d | Gerentes de Procesos [50%]; Gerentes de Proyecto 1 [50%]; Impresora [1 Unidad]; Luz [1 Gasto] | 24h | 10,787,840 | 10,787,840 |
| 90 | 1.10.1.2.4 | Reunion seguimiento | 0.12d | 2022-05-20 12:00 | 2022-05-20 13:00 | 89 | 2022-05-20 12:00 | 2022-05-20 13:00 | 0.12d | 0d | Gerentes de Procesos; Gerentes de Proyecto 1 | 2h | 812,320 | 812,320 |
| 91 | 1.10.1.3 | **1.5.1.3.Análisis de informe** | 2.12d | 2022-05-20 15:00 | 2022-05-24 16:00 |  | 2022-05-20 15:00 | 2022-05-24 16:00 | 2.12d | 0d |  | 18h | 12,850,880 | 12,850,880 |
| 92 | 1.10.1.3.1 | 1.5.1.3.1.INFOME DE MEJORAS | 2d | 2022-05-20 15:00 | 2022-05-24 13:00 | 90 | 2022-05-20 15:00 | 2022-05-24 13:00 | 2d | 0d | Gerentes de Procesos [50%]; Gerentes de Proyecto 1 [50%]; Impresora [1 Unidad]; Luz [1 Gasto]; Computadores portatiles [1 Unidad] | 16h | 12,038,560 | 12,038,560 |
| 93 | 1.10.1.3.2 | Reunion seguimiento | 0.12d | 2022-05-24 15:00 | 2022-05-24 16:00 | 92 | 2022-05-24 15:00 | 2022-05-24 16:00 | 0.12d | 0d | Gerentes de Proyecto 1; Gerentes de Procesos | 2h | 812,320 | 812,320 |
| 94 | 1.10.1.4 | **1.5.1.4.Planteamiento de mejoras** | 7.38d | 2022-05-24 16:00 | 2022-06-02 19:00 |  | 2022-05-24 16:00 | 2022-06-02 19:00 | 7.38d | 0d |  | 84h | 74,738,920 | 74,738,920 |
| 95 | 1.10.1.4.1 | 1.5.1.4.1.PLANTEAMIENTO DE MEJORAS | 4d | 2022-05-24 16:00 | 2022-05-30 16:00 | 93 | 2022-05-24 16:00 | 2022-05-30 16:00 | 4d | 0d | Gerentes de Procesos [50%]; Gerentes de Proyecto 1 [50%]; Computadores portatiles [1 Unidad]; Luz [1 Gasto] | 32h | 17,537,120 | 17,537,120 |
| 96 | 1.10.1.4.2 | Reunion seguimiento | 0.12d | 2022-05-30 16:00 | 2022-05-30 17:00 | 95 | 2022-05-30 16:00 | 2022-05-30 17:00 | 0.12d | 0d | Gerentes de Procesos; Gerentes de Proyecto 1 | 2h | 812,320 | 812,320 |
| 97 | 1.10.1.4.3 | 1.5.1.4.1.APROVACION DE MEJORAS | 1d | 2022-05-30 17:00 | 2022-05-31 17:00 | 96 | 2022-05-30 17:00 | 2022-05-31 17:00 | 1d | 0d | Computadores portatiles [1 Unidad]; Luz [1 Gasto]; Gerentes de Procesos [50%]; Gerentes de Proyecto 1 [50%] | 8h | 7,789,280 | 7,789,280 |
| 98 | 1.10.1.4.4 | Capacitacion Mejoras 1 | 0.12d | 2022-05-31 17:00 | 2022-05-31 18:00 | 97 | 2022-05-31 17:00 | 2022-05-31 18:00 | 0.12d | 0d | Gerentes de Procesos; Gerentes de Proyecto 1; Pofecional civil exp banco; Pofecional civil exp banco 2; Luz [1 Gasto]; Proyector [1 Unidad] | 4h | 4,778,788 | 4,778,788 |
| 99 | 1.10.1.4.5 | Capacitacion Mejoras 2 | 0.12d | 2022-05-31 18:00 | 2022-05-31 19:00 | 98 | 2022-05-31 18:00 | 2022-05-31 19:00 | 0.12d | 0d | Gerentes de Procesos; Gerentes de Proyecto 1; Pofecional civil exp banco; Pofecional civil exp banco 2; Luz [1 Gasto]; Proyector [1 Unidad] | 4h | 4,778,788 | 4,778,788 |
| 100 | 1.10.1.4.6 | Capacitacion Mejoras 3 | 0.12d | 2022-06-01 09:00 | 2022-06-01 10:00 | 99 | 2022-06-01 09:00 | 2022-06-01 10:00 | 0.12d | 0d | Gerentes de Proyecto 1; Gerentes de Procesos; Pofecional civil exp banco; Pofecional civil exp banco 2; Luz [1 Gasto]; Proyector [1 Unidad] | 4h | 4,778,788 | 4,778,788 |
| 101 | 1.10.1.4.7 | Capacitacion Mejoras 4 | 0.12d | 2022-06-01 10:00 | 2022-06-01 11:00 | 100 | 2022-06-01 10:00 | 2022-06-01 11:00 | 0.12d | 0d | Gerentes de Procesos; Gerentes de Proyecto 1; Pofecional civil exp banco; Pofecional civil exp banco 2; Luz [1 Gasto]; Proyector [1 Unidad] | 4h | 4,778,788 | 4,778,788 |
| 102 | 1.10.1.4.8 | Capacitacion Mejoras 5 | 0.12d | 2022-06-01 11:00 | 2022-06-01 12:00 | 101 | 2022-06-01 11:00 | 2022-06-01 12:00 | 0.12d | 0d | Gerentes de Procesos; Gerentes de Proyecto 1; Pofecional civil exp banco; Pofecional civil exp banco 2; Luz [1 Gasto]; Proyector [1 Unidad] | 4h | 4,778,788 | 4,778,788 |
| 103 | 1.10.1.4.9 | Capacitacion Mejoras 6 | 0.12d | 2022-06-01 12:00 | 2022-06-01 13:00 | 102 | 2022-06-01 12:00 | 2022-06-01 13:00 | 0.12d | 0d | Gerentes de Procesos; Gerentes de Proyecto 1; Pofecional civil exp banco; Pofecional civil exp banco 2; Luz [1 Gasto]; Proyector [1 Unidad] | 4h | 4,778,788 | 4,778,788 |
| 104 | 1.10.1.4.10 | Capacitacion Mejoras 7 | 0.12d | 2022-06-01 15:00 | 2022-06-01 16:00 | 103 | 2022-06-01 15:00 | 2022-06-01 16:00 | 0.12d | 0d | Gerentes de Procesos; Gerentes de Proyecto 1; Pofecional civil exp banco; Pofecional civil exp banco 2; Luz [1 Gasto]; Proyector [1 Unidad] | 4h | 4,778,788 | 4,778,788 |
| 105 | 1.10.1.4.11 | Capacitacion Mejoras 8 | 0.12d | 2022-06-01 16:00 | 2022-06-01 17:00 | 104 | 2022-06-01 16:00 | 2022-06-01 17:00 | 0.12d | 0d | Gerentes de Procesos; Gerentes de Proyecto 1; Pofecional civil exp banco; Pofecional civil exp banco 2; Luz [1 Gasto]; Proyector [1 Unidad] | 4h | 4,778,788 | 4,778,788 |
| 106 | 1.10.1.4.12 | Capacitacion Mejoras 9 | 0.12d | 2022-06-01 17:00 | 2022-06-01 18:00 | 105 | 2022-06-01 17:00 | 2022-06-01 18:00 | 0.12d | 0d | Gerentes de Procesos; Gerentes de Proyecto 1; Pofecional civil exp banco; Pofecional civil exp banco 2; Luz [1 Gasto]; Proyector [1 Unidad] | 4h | 4,778,788 | 4,778,788 |
| 107 | 1.10.1.4.13 | Capacitacion Mejoras 10 | 0.12d | 2022-06-01 18:00 | 2022-06-02 18:00 | 106 | 2022-06-01 18:00 | 2022-06-02 18:00 | 0.12d | 0d | Gerentes de Procesos; Gerentes de Proyecto 1; Luz [1 Gasto]; Proyector [1 Unidad]; Pofecional civil exp banco 2; Pofecional civil exp banco | 4h | 4,778,788 | 4,778,788 |
| 108 | 1.10.1.4.14 | Reunion seguimiento | 0.12d | 2022-06-02 18:00 | 2022-06-02 19:00 | 107 | 2022-06-02 18:00 | 2022-06-02 19:00 | 0.12d | 0d | Gerentes de Procesos; Gerentes de Proyecto 1 | 2h | 812,320 | 812,320 |

| ID | WBS | Task | Type | Duration | Start | Finish | Predecessors | Baseline start | Baseline finish | Baseline duration | Total slack | Free slack | Constraint | Resources | Work | Cost | Baseline cost |
| --- | --- | --- | --- | --- | --- | --- | --- | --- | --- | --- | --- | --- | --- | --- | --- | --- | --- |
| 109 | 1.10.2 | **1.5.2.Modificación de proceso** |  | 4.12d | 2022-06-03 09:00 | 2022-06-09 10:00 |  | 2022-06-03 09:00 | 2022-06-09 10:00 | 4.12d | 0d |  |  |  | 34h | 24,349,440 | 24,349,440 |
| 110 | 1.10.2.1 | 1.5.2.1IMPLEMENTACION DE PROCESO |  | 4d | 2022-06-03 09:00 | 2022-06-08 19:00 | 108 | 2022-06-03 09:00 | 2022-06-08 19:00 | 4d | 0d |  |  | Computadores portatiles [1 Unidad]; Celulares [1 Unidad]; Gerentes de Procesos [50%]; Gerentes de Proyecto 1 [50%]; Luz [1 Gasto]; Impresora [1 Unidad] | 32h | 23,537,120 | 23,537,120 |
| 111 | 1.10.2.2 | Reunion seguimiento |  | 0.12d | 2022-06-09 09:00 | 2022-06-09 10:00 | 110 | 2022-06-09 09:00 | 2022-06-09 10:00 | 0.12d | 0d |  |  | Gerentes de Procesos; Gerentes de Proyecto 1 | 2h | 812,320 | 812,320 |
| 112 | 1.10.3 | **1.5.3.Implementación de cambios Aprobados** |  | 1.12d | 2022-06-09 10:00 | 2022-06-10 11:00 |  | 2022-06-09 10:00 | 2022-06-10 11:00 | 1.12d | 0d |  |  |  | 10h | 12,101,600 | 12,101,600 |
| 113 | 1.10.3.1 | 1.5.3.1.INFORME DE PROVACIÓN |  | 1d | 2022-06-09 10:00 | 2022-06-10 10:00 | 111 | 2022-06-09 10:00 | 2022-06-10 10:00 | 1d | 0d |  |  | Computadores portatiles [1 Unidad]; Luz [1 Gasto]; Gerentes de Procesos [50%]; Gerentes de Proyecto 1 [50%]; Proyector [1 Unidad] | 8h | 11,289,280 | 11,289,280 |
| 114 | 1.10.3.2 | Reunion seguimiento |  | 0.12d | 2022-06-10 10:00 | 2022-06-10 11:00 | 113 | 2022-06-10 10:00 | 2022-06-10 11:00 | 0.12d | 0d |  |  | Gerentes de Procesos; Gerentes de Proyecto 1 | 2h | 812,320 | 812,320 |
| 115 | 1.11 | FACE DE OPERACIÓN TERMINADO | milestone | 0d | 2022-06-10 11:00 | 2022-06-10 11:00 | 114 | 2022-06-10 11:00 | 2022-06-10 11:00 | 0d | 0d |  |  |  |  |  |  |
| 116 | 1.12 | **1.6.Gerencia del Proyecto** |  | 80.62d? | 2022-01-06 09:00 | 2022-04-28 16:00 |  | 2022-01-06 09:00 | 2022-04-28 16:00 | 80.62d? | 30.62d |  |  |  | 642h | 424,194,720 | 424,194,720 |
| 117 | 1.12.1 | **1.6.1.Inicio** |  | 3.38d | 2022-01-06 09:00 | 2022-01-11 12:00 |  | 2022-01-06 09:00 | 2022-01-11 12:00 | 3.38d | 30.62d |  |  |  | 30h | 25,804,800 | 25,804,800 |
| 118 | 1.12.1.1 | 1.6.1.1.Acta de constitución |  | 1d | 2022-01-06 09:00 | 2022-01-06 19:00 | 5 | 2022-01-06 09:00 | 2022-01-06 19:00 | 1d | 30.62d | 0d | start no earlier than 2022-01-03 09:00 | Gerentes de Procesos [50%]; Gerentes de Proyecto 1 [50%]; Computadores portatiles [1 Unidad]; Luz [1 Gasto] | 8h | 7,789,280 | 7,789,280 |
| 119 | 1.12.1.2 | Reunion seguimiento |  | 0.12d | 2022-01-07 09:00 | 2022-01-07 10:00 | 118 | 2022-01-07 09:00 | 2022-01-07 10:00 | 0.12d | 30.62d | 0d |  | Gerentes de Procesos; Gerentes de Proyecto 1 | 2h | 812,320 | 812,320 |
| 120 | 1.12.1.3 | 1.6.1.2.Identificación de stake holders |  | 1d | 2022-01-07 10:00 | 2022-01-10 10:00 | 119 | 2022-01-07 10:00 | 2022-01-10 10:00 | 1d | 30.62d | 0d |  | Gerentes de Procesos [50%]; Gerentes de Proyecto 1 [50%]; Computadores portatiles [1 Unidad]; Luz [1 Gasto] | 8h | 7,789,280 | 7,789,280 |
| 121 | 1.12.1.4 | Reunion seguimiento |  | 0.12d | 2022-01-10 10:00 | 2022-01-10 11:00 | 120 | 2022-01-10 10:00 | 2022-01-10 11:00 | 0.12d | 30.62d | 0d |  | Gerentes de Procesos; Gerentes de Proyecto 1 | 2h | 812,320 | 812,320 |
| 122 | 1.12.1.5 | 1.6.2.Planes de Gestión del proyecto |  | 1d | 2022-01-10 11:00 | 2022-01-11 11:00 | 121 | 2022-01-10 11:00 | 2022-01-11 11:00 | 1d | 30.62d | 0d |  | Gerentes de Procesos [50%]; Gerentes de Proyecto 1 [50%]; Computadores portatiles [1 Unidad]; Luz [1 Gasto] | 8h | 7,789,280 | 7,789,280 |
| 123 | 1.12.1.6 | Reunion seguimiento |  | 0.12d | 2022-01-11 11:00 | 2022-01-11 12:00 | 122 | 2022-01-11 11:00 | 2022-01-11 12:00 | 0.12d | 30.62d | 0d |  | Gerentes de Procesos; Gerentes de Proyecto 1 | 2h | 812,320 | 812,320 |
| 124 | 1.12.2 | **PLAN DE GESTIÓN DE LOS INTERESADOS FINALIZADO** |  | 7.12d | 2022-01-11 12:00 | 2022-01-20 13:00 |  | 2022-01-11 12:00 | 2022-01-20 13:00 | 7.12d | 30.62d |  |  |  | 50h | 38,468,000 | 38,468,000 |
| 125 | 1.12.2.1 | ELABORAR DOCUMENTO DE INTERESADOS |  | 1d | 2022-01-11 12:00 | 2022-01-12 12:00 | 123 | 2022-01-11 12:00 | 2022-01-12 12:00 | 1d | 30.62d | 0d |  | Gerentes de Procesos [50%]; Gerentes de Proyecto 1 [50%]; Computadores portatiles [1 Unidad]; Luz [1 Gasto] | 8h | 7,789,280 | 7,789,280 |
| 126 | 1.12.2.2 | Reunion seguimiento |  | 1d | 2022-01-12 12:00 | 2022-01-13 12:00 | 125 | 2022-01-12 12:00 | 2022-01-13 12:00 | 1d | 30.62d | 0d |  |  |  |  |  |
| 127 | 1.12.2.3 | SOCIALIZACION DOCUMENTO DE INTERESADOS |  | 3d | 2022-01-13 12:00 | 2022-01-18 12:00 | 126 | 2022-01-13 12:00 | 2022-01-18 12:00 | 3d | 30.62d | 0d |  | Gerentes de Procesos [50%]; Gerentes de Proyecto 1 [50%]; Computadores portatiles [1 Unidad]; Luz [1 Gasto] | 24h | 14,287,840 | 14,287,840 |
| 128 | 1.12.2.4 | Reunion seguimiento |  | 0.12d | 2022-01-18 12:00 | 2022-01-18 13:00 | 127 | 2022-01-18 12:00 | 2022-01-18 13:00 | 0.12d | 30.62d | 0d |  | Gerentes de Procesos; Gerentes de Proyecto 1 | 2h | 812,320 | 812,320 |
| 129 | 1.12.2.5 | REUNION DE APROBACION DE DOCUMENTO DE INTERESADOS |  | 1d | 2022-01-18 15:00 | 2022-01-19 13:00 | 128 | 2022-01-18 15:00 | 2022-01-19 13:00 | 1d | 30.62d | 0d |  | Gerentes de Procesos [50%]; Gerentes de Proyecto 1 [50%]; Computadores portatiles [1 Unidad]; Luz [1 Gasto] | 8h | 7,789,280 | 7,789,280 |
| 130 | 1.12.2.6 | REUNION DE SEGUIMIENTO |  | 1d | 2022-01-19 15:00 | 2022-01-20 13:00 | 129 | 2022-01-19 15:00 | 2022-01-20 13:00 | 1d | 30.62d | 0d |  | Gerentes de Procesos [50%]; Gerentes de Proyecto 1 [50%]; Computadores portatiles [1 Unidad]; Luz [1 Gasto] | 8h | 7,789,280 | 7,789,280 |
| 131 | 1.12.3 | **PLAN DE GESTIÓN DE ALCANCE FINALIZADO** |  | 6.38d | 2022-01-20 15:00 | 2022-01-28 18:00 |  | 2022-01-20 15:00 | 2022-01-28 18:00 | 6.38d | 30.62d |  |  |  | 54h | 35,552,640 | 35,552,640 |
| 132 | 1.12.3.1 | ELABORAR DOCUMENTO DE ALCANCE |  | 2d | 2022-01-20 15:00 | 2022-01-24 13:00 | 130 | 2022-01-20 15:00 | 2022-01-24 13:00 | 2d | 30.62d | 0d |  | Gerentes de Procesos [50%]; Gerentes de Proyecto 1 [50%]; Computadores portatiles [1 Unidad]; Luz [1 Gasto] | 16h | 11,038,560 | 11,038,560 |
| 133 | 1.12.3.2 | Reunion seguimiento |  | 0.12d | 2022-01-24 15:00 | 2022-01-24 16:00 | 132 | 2022-01-24 15:00 | 2022-01-24 16:00 | 0.12d | 30.62d | 0d |  | Gerentes de Procesos; Gerentes de Proyecto 1 | 2h | 812,320 | 812,320 |
| 134 | 1.12.3.3 | SOCIALIZACION DOCUMENTO DE ALCANCE |  | 3d | 2022-01-24 16:00 | 2022-01-27 16:00 | 133 | 2022-01-24 16:00 | 2022-01-27 16:00 | 3d | 30.62d | 0d |  | Gerentes de Procesos [50%]; Gerentes de Proyecto 1 [50%]; Computadores portatiles [1 Unidad]; Luz [1 Gasto] | 24h | 14,287,840 | 14,287,840 |
| 135 | 1.12.3.4 | Reunion seguimiento |  | 0.12d | 2022-01-27 16:00 | 2022-01-27 17:00 | 134 | 2022-01-27 16:00 | 2022-01-27 17:00 | 0.12d | 30.62d | 0d |  | Gerentes de Procesos; Gerentes de Proyecto 1 | 2h | 812,320 | 812,320 |
| 136 | 1.12.3.5 | REUNION DE APROBACION DE DOCUMENTO DE ALCANCE |  | 1d | 2022-01-27 17:00 | 2022-01-28 17:00 | 135 | 2022-01-27 17:00 | 2022-01-28 17:00 | 1d | 30.62d | 0d |  | Gerentes de Procesos [50%]; Gerentes de Proyecto 1 [50%]; Computadores portatiles [1 Unidad]; Luz [1 Gasto] | 8h | 7,789,280 | 7,789,280 |
| 137 | 1.12.3.6 | Reunion seguimiento |  | 0.12d | 2022-01-28 17:00 | 2022-01-28 18:00 | 136 | 2022-01-28 17:00 | 2022-01-28 18:00 | 0.12d | 30.62d | 0d |  | Gerentes de Procesos; Gerentes de Proyecto 1 | 2h | 812,320 | 812,320 |

| ID | WBS | Task | Duration | Start | Finish | Predecessors | Baseline start | Baseline finish | Baseline duration | Total slack | Free slack | Resources | Work | Cost | Baseline cost |
| --- | --- | --- | --- | --- | --- | --- | --- | --- | --- | --- | --- | --- | --- | --- | --- |
| 138 | 1.12.4 | **PLAN DE GESTIÓN DE CRONOGRAMA** | 4.38d | 2022-01-28 18:00 | 2022-02-04 11:00 |  | 2022-01-28 18:00 | 2022-02-04 11:00 | 4.38d | 30.62d |  |  | 38h | 29,054,080 | 29,054,080 |
| 139 | 1.12.4.1 | ELABORAR DOCUMENTO DE CRONOGRAMA | 1d | 2022-01-28 18:00 | 2022-01-31 18:00 | 137 | 2022-01-28 18:00 | 2022-01-31 18:00 | 1d | 30.62d | 0d | Gerentes de Procesos [50%]; Gerentes de Proyecto 1 [50%]; Computadores portatiles [1 Unidad]; Luz [1 Gasto] | 8h | 7,789,280 | 7,789,280 |
| 140 | 1.12.4.2 | Reunion seguimiento | 0.12d | 2022-01-31 18:00 | 2022-01-31 19:00 | 139 | 2022-01-31 18:00 | 2022-01-31 19:00 | 0.12d | 30.62d | 0d | Gerentes de Procesos; Gerentes de Proyecto 1 | 2h | 812,320 | 812,320 |
| 141 | 1.12.4.3 | SOCIALIZACION DOCUMENTO DE CRONOGRAMA | 2d | 2022-02-01 09:00 | 2022-02-02 19:00 | 140 | 2022-02-01 09:00 | 2022-02-02 19:00 | 2d | 30.62d | 0d | Gerentes de Procesos [50%]; Gerentes de Proyecto 1 [50%]; Computadores portatiles [1 Unidad]; Luz [1 Gasto] | 16h | 11,038,560 | 11,038,560 |
| 142 | 1.12.4.4 | Reunion seguimiento | 0.12d | 2022-02-03 09:00 | 2022-02-03 10:00 | 141 | 2022-02-03 09:00 | 2022-02-03 10:00 | 0.12d | 30.62d | 0d | Gerentes de Procesos; Gerentes de Proyecto 1 | 2h | 812,320 | 812,320 |
| 143 | 1.12.4.5 | REUNION DE APROBACION DE DOCUMENTO DE CRONOGRAMA | 1d | 2022-02-03 10:00 | 2022-02-04 10:00 | 142 | 2022-02-03 10:00 | 2022-02-04 10:00 | 1d | 30.62d | 0d | Gerentes de Procesos [50%]; Gerentes de Proyecto 1 [50%]; Computadores portatiles [1 Unidad]; Luz [1 Gasto] | 8h | 7,789,280 | 7,789,280 |
| 144 | 1.12.4.6 | Reunion seguimiento | 0.12d | 2022-02-04 10:00 | 2022-02-04 11:00 | 143 | 2022-02-04 10:00 | 2022-02-04 11:00 | 0.12d | 30.62d | 0d | Gerentes de Procesos; Gerentes de Proyecto 1 | 2h | 812,320 | 812,320 |
| 145 | 1.12.5 | **PLAN DE GESTIÓN DE COSTOS FINALIZADO** | 6.38d | 2022-02-04 11:00 | 2022-02-14 16:00 |  | 2022-02-04 11:00 | 2022-02-14 16:00 | 6.38d | 30.62d |  |  | 54h | 35,552,640 | 35,552,640 |
| 146 | 1.12.5.1 | ELABORAR DOCUMENTO DE COSTOS | 1d | 2022-02-04 11:00 | 2022-02-07 11:00 | 144 | 2022-02-04 11:00 | 2022-02-07 11:00 | 1d | 30.62d | 0d | Gerentes de Procesos [50%]; Gerentes de Proyecto 1 [50%]; Computadores portatiles [1 Unidad]; Luz [1 Gasto] | 8h | 7,789,280 | 7,789,280 |
| 147 | 1.12.5.2 | Reunion seguimiento | 0.12d | 2022-02-07 11:00 | 2022-02-07 12:00 | 146 | 2022-02-07 11:00 | 2022-02-07 12:00 | 0.12d | 30.62d | 0d | Gerentes de Procesos; Gerentes de Proyecto 1 | 2h | 812,320 | 812,320 |
| 148 | 1.12.5.3 | SOCIALIZACION DOCUMENTO DE COSTOS | 4d | 2022-02-07 12:00 | 2022-02-11 12:00 | 147 | 2022-02-07 12:00 | 2022-02-11 12:00 | 4d | 30.62d | 0d | Gerentes de Procesos [50%]; Gerentes de Proyecto 1 [50%]; Computadores portatiles [1 Unidad]; Luz [1 Gasto] | 32h | 17,537,120 | 17,537,120 |
| 149 | 1.12.5.4 | Reunion seguimiento | 0.12d | 2022-02-11 12:00 | 2022-02-11 13:00 | 148 | 2022-02-11 12:00 | 2022-02-11 13:00 | 0.12d | 30.62d | 0d | Gerentes de Procesos; Gerentes de Proyecto 1 | 2h | 812,320 | 812,320 |
| 150 | 1.12.5.5 | REUNION DE APROBACION DE DOCUMENTO DE COSTOS | 1d | 2022-02-11 15:00 | 2022-02-14 13:00 | 149 | 2022-02-11 15:00 | 2022-02-14 13:00 | 1d | 30.62d | 0d | Gerentes de Procesos [50%]; Gerentes de Proyecto 1 [50%]; Computadores portatiles [1 Unidad]; Luz [1 Gasto] | 8h | 7,789,280 | 7,789,280 |
| 151 | 1.12.5.6 | Reunion seguimiento | 0.12d | 2022-02-14 15:00 | 2022-02-14 16:00 | 150 | 2022-02-14 15:00 | 2022-02-14 16:00 | 0.12d | 30.62d | 0d | Gerentes de Procesos; Gerentes de Proyecto 1 | 2h | 812,320 | 812,320 |
| 152 | 1.12.6 | **PLAN DE GESTIÓN DE CALIDAD FINALIZADO** | 7.38d | 2022-02-14 16:00 | 2022-02-23 19:00 |  | 2022-02-14 16:00 | 2022-02-23 19:00 | 7.38d | 30.62d |  |  | 62h | 38,801,920 | 38,801,920 |
| 153 | 1.12.6.1 | ELABORAR DOCUMENTO DE CALIDAD | 1d | 2022-02-14 16:00 | 2022-02-15 16:00 | 151 | 2022-02-14 16:00 | 2022-02-15 16:00 | 1d | 30.62d | 0d | Gerentes de Procesos [50%]; Gerentes de Proyecto 1 [50%]; Computadores portatiles [1 Unidad]; Luz [1 Gasto] | 8h | 7,789,280 | 7,789,280 |
| 154 | 1.12.6.2 | Reunion seguimiento | 0.12d | 2022-02-15 16:00 | 2022-02-15 17:00 | 153 | 2022-02-15 16:00 | 2022-02-15 17:00 | 0.12d | 30.62d | 0d | Gerentes de Procesos; Gerentes de Proyecto 1 | 2h | 812,320 | 812,320 |
| 155 | 1.12.6.3 | SOCIALIZACION DOCUMENTO DE CALIDAD | 5d | 2022-02-15 17:00 | 2022-02-22 17:00 | 154 | 2022-02-15 17:00 | 2022-02-22 17:00 | 5d | 30.62d | 0d | Gerentes de Procesos [50%]; Gerentes de Proyecto 1 [50%]; Computadores portatiles [1 Unidad]; Luz [1 Gasto] | 40h | 20,786,400 | 20,786,400 |
| 156 | 1.12.6.4 | Reunion seguimiento | 0.12d | 2022-02-22 17:00 | 2022-02-22 18:00 | 155 | 2022-02-22 17:00 | 2022-02-22 18:00 | 0.12d | 30.62d | 0d | Gerentes de Procesos; Gerentes de Proyecto 1 | 2h | 812,320 | 812,320 |
| 157 | 1.12.6.5 | REUNION DE APROBACION DE DOCUMENTO DE CALIDAD | 1d | 2022-02-22 18:00 | 2022-02-23 18:00 | 156 | 2022-02-22 18:00 | 2022-02-23 18:00 | 1d | 30.62d | 0d | Gerentes de Procesos [50%]; Gerentes de Proyecto 1 [50%]; Computadores portatiles [1 Unidad]; Luz [1 Gasto] | 8h | 7,789,280 | 7,789,280 |
| 158 | 1.12.6.6 | Reunion seguimiento | 0.12d | 2022-02-23 18:00 | 2022-02-23 19:00 | 157 | 2022-02-23 18:00 | 2022-02-23 19:00 | 0.12d | 30.62d | 0d | Gerentes de Procesos; Gerentes de Proyecto 1 | 2h | 812,320 | 812,320 |
| 159 | 1.12.7 | **PLAN DE GESTIÓN DE LOS RECURSOS HUMANOS FINALIZADO** | 7.25d? | 2022-02-24 09:00 | 2022-03-07 11:00 |  | 2022-02-24 09:00 | 2022-03-07 11:00 | 7.25d? | 30.62d |  |  | 52h | 34,740,320 | 34,740,320 |
| 160 | 1.12.7.1 | ELABORAR DOCUMENTO DE RECURSOS HUMANOS | 1d | 2022-02-24 09:00 | 2022-02-24 19:00 | 158 | 2022-02-24 09:00 | 2022-02-24 19:00 | 1d | 30.62d | 0d | Gerentes de Procesos [50%]; Gerentes de Proyecto 1 [50%]; Computadores portatiles [1 Unidad]; Luz [1 Gasto] | 8h | 7,789,280 | 7,789,280 |
| 161 | 1.12.7.2 | Reunion seguimiento | 0.12d | 2022-02-25 09:00 | 2022-02-25 10:00 | 160 | 2022-02-25 09:00 | 2022-02-25 10:00 | 0.12d | 30.62d | 0d | Gerentes de Procesos; Gerentes de Proyecto 1 | 2h | 812,320 | 812,320 |
| 162 | 1.12.7.3 | SOCIALIZACION DOCUMENTO DE LOS RECUROS HUMANOS | 4d | 2022-02-25 10:00 | 2022-03-03 10:00 | 161 | 2022-02-25 10:00 | 2022-03-03 10:00 | 4d | 30.62d | 0d | Gerentes de Procesos [50%]; Gerentes de Proyecto 1 [50%]; Computadores portatiles [1 Unidad]; Luz [1 Gasto] | 32h | 17,537,120 | 17,537,120 |
| 163 | 1.12.7.4 | Reunion seguimiento | 0.12d | 2022-03-03 10:00 | 2022-03-03 11:00 | 162 | 2022-03-03 10:00 | 2022-03-03 11:00 | 0.12d | 30.62d | 0d | Gerentes de Procesos; Gerentes de Proyecto 1 | 2h | 812,320 | 812,320 |
| 164 | 1.12.7.5 | REUNION DE APROBACION DE DOCUMENTO DE RECURSOS HUMANOS | 1d | 2022-03-03 11:00 | 2022-03-04 11:00 | 163 | 2022-03-03 11:00 | 2022-03-04 11:00 | 1d | 30.62d | 0d | Gerentes de Procesos [50%]; Gerentes de Proyecto 1 [50%]; Computadores portatiles [1 Unidad]; Luz [1 Gasto] | 8h | 7,789,280 | 7,789,280 |
| 165 | 1.12.7.6 | Reunion seguimiento | 1d? | 2022-03-04 11:00 | 2022-03-07 11:00 | 164 | 2022-03-04 11:00 | 2022-03-07 11:00 | 1d? | 69d |  |  |  |  |  |

| ID | WBS | Task | Duration | Start | Finish | Predecessors | Baseline start | Baseline finish | Baseline duration | Total slack | Free slack | Resources | Work | Cost | Baseline cost |
| --- | --- | --- | --- | --- | --- | --- | --- | --- | --- | --- | --- | --- | --- | --- | --- |
| 166 | 1.12.8 | **PLAN DE GESTIÓN COMUNICACIONES FINALIZADO** | 7.38d | 2022-03-04 11:00 | 2022-03-15 16:00 |  | 2022-03-04 11:00 | 2022-03-15 16:00 | 7.38d | 30.62d |  |  | 62h | 38,801,920 | 38,801,920 |
| 167 | 1.12.8.1 | ELABORAR DOCUMENTO DE COMUNICACIONES | 3d | 2022-03-04 11:00 | 2022-03-09 11:00 | 164 | 2022-03-04 11:00 | 2022-03-09 11:00 | 3d | 30.62d | 0d | Gerentes de Procesos [50%]; Gerentes de Proyecto 1 [50%]; Computadores portatiles [1 Unidad]; Luz [1 Gasto] | 24h | 14,287,840 | 14,287,840 |
| 168 | 1.12.8.2 | Reunion seguimiento | 0.12d | 2022-03-09 11:00 | 2022-03-09 12:00 | 167 | 2022-03-09 11:00 | 2022-03-09 12:00 | 0.12d | 30.62d | 0d | Gerentes de Procesos; Gerentes de Proyecto 1 | 2h | 812,320 | 812,320 |
| 169 | 1.12.8.3 | SOCIALIZACION DOCUMENTO DE COMUNICACIONES | 3d | 2022-03-09 12:00 | 2022-03-14 12:00 | 168 | 2022-03-09 12:00 | 2022-03-14 12:00 | 3d | 30.62d | 0d | Gerentes de Procesos [50%]; Gerentes de Proyecto 1 [50%]; Computadores portatiles [1 Unidad]; Luz [1 Gasto] | 24h | 14,287,840 | 14,287,840 |
| 170 | 1.12.8.4 | Reunion seguimiento | 0.12d | 2022-03-14 12:00 | 2022-03-14 13:00 | 169 | 2022-03-14 12:00 | 2022-03-14 13:00 | 0.12d | 30.62d | 0d | Gerentes de Procesos; Gerentes de Proyecto 1 | 2h | 812,320 | 812,320 |
| 171 | 1.12.8.5 | REUNION DE APROBACION DE DOCUMENTO DE COMUNICACIONES | 1d | 2022-03-14 15:00 | 2022-03-15 13:00 | 170 | 2022-03-14 15:00 | 2022-03-15 13:00 | 1d | 30.62d | 0d | Gerentes de Procesos [50%]; Gerentes de Proyecto 1 [50%]; Computadores portatiles [1 Unidad]; Luz [1 Gasto] | 8h | 7,789,280 | 7,789,280 |
| 172 | 1.12.8.6 | Reunion seguimiento | 0.12d | 2022-03-15 15:00 | 2022-03-15 16:00 | 171 | 2022-03-15 15:00 | 2022-03-15 16:00 | 0.12d | 30.62d | 0d | Gerentes de Procesos; Gerentes de Proyecto 1 | 2h | 812,320 | 812,320 |
| 173 | 1.12.9 | **PLAN DE GESTIÓN DE RIESGOS FINALIZADO** | 8.38d? | 2022-03-15 16:00 | 2022-03-25 19:00 |  | 2022-03-15 16:00 | 2022-03-25 19:00 | 8.38d? | 30.62d |  |  | 70h | 42,051,200 | 42,051,200 |
| 174 | 1.12.9.1 | ELABORAR DOCUMENTO DE RIESGOS | 3d | 2022-03-15 16:00 | 2022-03-18 16:00 | 172 | 2022-03-15 16:00 | 2022-03-18 16:00 | 3d | 30.62d | 0d | Gerentes de Procesos [50%]; Gerentes de Proyecto 1 [50%]; Computadores portatiles [1 Unidad]; Luz [1 Gasto] | 24h | 14,287,840 | 14,287,840 |
| 175 | 1.12.9.2 | Reunion seguimiento | 0.12d | 2022-03-18 16:00 | 2022-03-18 17:00 | 174 | 2022-03-18 16:00 | 2022-03-18 17:00 | 0.12d | 30.62d | 0d | Gerentes de Procesos; Gerentes de Proyecto 1 | 2h | 812,320 | 812,320 |
| 176 | 1.12.9.3 | SOCIALIZACION DOCUMENTO DE RIESGOS | 4d | 2022-03-18 17:00 | 2022-03-24 17:00 | 175 | 2022-03-18 17:00 | 2022-03-24 17:00 | 4d | 30.62d | 0d | Gerentes de Procesos [50%]; Gerentes de Proyecto 1 [50%]; Computadores portatiles [1 Unidad]; Luz [1 Gasto] | 32h | 17,537,120 | 17,537,120 |
| 177 | 1.12.9.4 | Reunion seguimiento | 0.12d | 2022-03-24 17:00 | 2022-03-24 18:00 | 176 | 2022-03-24 17:00 | 2022-03-24 18:00 | 0.12d | 30.62d | 0d | Gerentes de Procesos; Gerentes de Proyecto 1 | 2h | 812,320 | 812,320 |
| 178 | 1.12.9.5 | REUNION DE APROBACION DE DOCUMENTO DE RIESGOS | 1d | 2022-03-24 18:00 | 2022-03-25 18:00 | 177 | 2022-03-24 18:00 | 2022-03-25 18:00 | 1d | 30.62d | 0d | Gerentes de Proyecto 1 [50%]; Gerentes de Procesos [50%]; Computadores portatiles [1 Unidad]; Luz [1 Gasto] | 8h | 7,789,280 | 7,789,280 |
| 179 | 1.12.9.6 | Reunion seguimiento | 0.12d? | 2022-03-25 18:00 | 2022-03-25 19:00 | 178 | 2022-03-25 18:00 | 2022-03-25 19:00 | 0.12d? | 30.62d | 0d | Gerentes de Procesos; Gerentes de Proyecto 1 | 2h | 812,320 | 812,320 |
| 180 | 1.12.10 | **PLAN DE GESTIÓN DE LAS ADQUISICIONES FINALIZADO** | 11d | 2022-03-28 09:00 | 2022-04-11 19:00 |  | 2022-03-28 09:00 | 2022-04-11 19:00 | 11d | 30.62d |  |  | 64h | 39,614,240 | 39,614,240 |
| 181 | 1.12.10.1 | ELABORACIÒN DOCUMENTO DE ADQUISICIONES | 2d | 2022-03-28 09:00 | 2022-03-29 19:00 | 179 | 2022-03-28 09:00 | 2022-03-29 19:00 | 2d | 30.62d | 0d | Gerentes de Procesos [50%]; Gerentes de Proyecto 1 [50%]; Computadores portatiles [1 Unidad]; Luz [1 Gasto] | 16h | 11,038,560 | 11,038,560 |
| 182 | 1.12.10.2 | Reunion seguimiento | 1d | 2022-03-30 09:00 | 2022-03-30 19:00 | 181 | 2022-03-30 09:00 | 2022-03-30 19:00 | 1d | 30.62d | 0d |  |  |  |  |
| 183 | 1.12.10.3 | SOCIALIZACIÒN DOCUMENTO DE ADQUISICIONES | 5d | 2022-03-31 09:00 | 2022-04-06 19:00 | 182 | 2022-03-31 09:00 | 2022-04-06 19:00 | 5d | 30.62d | 0d | Gerentes de Procesos [50%]; Gerentes de Proyecto 1 [50%]; Computadores portatiles [1 Unidad]; Luz [1 Gasto] | 40h | 20,786,400 | 20,786,400 |
| 184 | 1.12.10.4 | Reunion seguimiento | 1d | 2022-04-07 09:00 | 2022-04-07 19:00 | 183 | 2022-04-07 09:00 | 2022-04-07 19:00 | 1d | 30.62d | 0d |  |  |  |  |
| 185 | 1.12.10.5 | REUNION DE APROBACION DE DOCUMENTO DE RIESGOS | 1d | 2022-04-08 09:00 | 2022-04-08 19:00 | 184 | 2022-04-08 09:00 | 2022-04-08 19:00 | 1d | 30.62d | 0d | Gerentes de Procesos [50%]; Gerentes de Proyecto 1 [50%]; Computadores portatiles [1 Unidad]; Luz [1 Gasto] | 8h | 7,789,280 | 7,789,280 |
| 186 | 1.12.10.6 | Reunion seguimiento | 1d | 2022-04-11 09:00 | 2022-04-11 19:00 | 185 | 2022-04-11 09:00 | 2022-04-11 19:00 | 1d | 30.62d | 0d |  |  |  |  |
| 187 | 1.12.11 | **PLAN DE GESTIÓN DE INTEGRACIÓN FINALIZADO** | 6.38d | 2022-04-12 09:00 | 2022-04-20 12:00 |  | 2022-04-12 09:00 | 2022-04-20 12:00 | 6.38d | 30.62d |  |  | 54h | 35,552,640 | 35,552,640 |
| 188 | 1.12.11.1 | ELABORAR DOCUMENTO DE INTEGRACIÒN | 1d | 2022-04-12 09:00 | 2022-04-12 19:00 | 186 | 2022-04-12 09:00 | 2022-04-12 19:00 | 1d | 30.62d | 0d | Gerentes de Procesos [50%]; Gerentes de Proyecto 1 [50%]; Computadores portatiles [1 Unidad]; Luz [1 Gasto] | 8h | 7,789,280 | 7,789,280 |
| 189 | 1.12.11.2 | Reunion seguimiento | 0.12d | 2022-04-13 09:00 | 2022-04-13 10:00 | 188 | 2022-04-13 09:00 | 2022-04-13 10:00 | 0.12d | 30.62d | 0d | Gerentes de Procesos; Gerentes de Proyecto 1 | 2h | 812,320 | 812,320 |
| 190 | 1.12.11.3 | SOCIALIZACION DOCUMENTO DE INTEGRACIÒN | 4d | 2022-04-13 10:00 | 2022-04-19 10:00 | 189 | 2022-04-13 10:00 | 2022-04-19 10:00 | 4d | 30.62d | 0d | Gerentes de Procesos [50%]; Gerentes de Proyecto 1 [50%]; Computadores portatiles [1 Unidad]; Luz [1 Gasto] | 32h | 17,537,120 | 17,537,120 |
| 191 | 1.12.11.4 | Reunion seguimiento | 0.12d | 2022-04-19 10:00 | 2022-04-19 11:00 | 190 | 2022-04-19 10:00 | 2022-04-19 11:00 | 0.12d | 30.62d | 0d | Gerentes de Procesos; Gerentes de Proyecto 1 | 2h | 812,320 | 812,320 |
| 192 | 1.12.11.5 | REUNION DE APROBACION DE DOCUMENTO DE INTEGRACIÒN | 1d | 2022-04-19 11:00 | 2022-04-20 11:00 | 191 | 2022-04-19 11:00 | 2022-04-20 11:00 | 1d | 30.62d | 0d | Gerentes de Procesos [50%]; Gerentes de Proyecto 1 [50%]; Computadores portatiles [1 Unidad]; Luz [1 Gasto] | 8h | 7,789,280 | 7,789,280 |
| 193 | 1.12.11.6 | Reunion seguimiento | 0.12d | 2022-04-20 11:00 | 2022-04-20 12:00 | 192 | 2022-04-20 11:00 | 2022-04-20 12:00 | 0.12d | 30.62d | 0d | Gerentes de Procesos; Gerentes de Proyecto 1 | 2h | 812,320 | 812,320 |

| ID | WBS | Task | Type | Duration | Start | Finish | Predecessors | Baseline start | Baseline finish | Baseline duration | Total slack | Free slack | Resources | Work | Cost | Baseline cost |
| --- | --- | --- | --- | --- | --- | --- | --- | --- | --- | --- | --- | --- | --- | --- | --- | --- |
| 194 | 1.12.12 | **Control Seguimiento** |  | 3d | 2022-04-20 12:00 | 2022-04-25 12:00 |  | 2022-04-20 12:00 | 2022-04-25 12:00 | 3d | 30.62d |  |  | 24h | 18,827,840 | 18,827,840 |
| 195 | 1.12.12.1 | Reunión de Seguimiento mensual |  | 1d | 2022-04-20 12:00 | 2022-04-21 12:00 | 193 | 2022-04-20 12:00 | 2022-04-21 12:00 | 1d | 30.62d | 0d | Gerentes de Procesos [50%]; Gerentes de Proyecto 1 [50%]; Computadores portatiles [1 Unidad]; Luz [1 Gasto] | 8h | 7,789,280 | 7,789,280 |
| 196 | 1.12.12.2 | Informe de desempeño del trabajo |  | 1d | 2022-04-21 12:00 | 2022-04-22 12:00 | 195 | 2022-04-21 12:00 | 2022-04-22 12:00 | 1d | 30.62d | 0d | Gerentes de Procesos [50%]; Gerentes de Proyecto 1 [50%]; Luz [1 Gasto]; Computadores portatiles [1 Unidad] | 8h | 7,789,280 | 7,789,280 |
| 197 | 1.12.12.3 | Acta de la reunión |  | 1d | 2022-04-22 12:00 | 2022-04-25 12:00 | 196 | 2022-04-22 12:00 | 2022-04-25 12:00 | 1d | 30.62d | 0d | Gerentes de Procesos [50%]; Gerentes de Proyecto 1 [50%] | 8h | 3,249,280 | 3,249,280 |
| 198 | 1.12.13 | **Cierre** |  | 3.25d | 2022-04-25 12:00 | 2022-04-28 16:00 |  | 2022-04-25 12:00 | 2022-04-28 16:00 | 3.25d | 30.62d |  |  | 28h | 11,372,480 | 11,372,480 |
| 199 | 1.12.13.1 | Cierre Administrativo |  | 1d | 2022-04-25 12:00 | 2022-04-26 12:00 | 197 | 2022-04-25 12:00 | 2022-04-26 12:00 | 1d | 30.62d | 0d | Gerentes de Procesos [50%]; Gerentes de Proyecto 1 [50%] | 8h | 3,249,280 | 3,249,280 |
| 200 | 1.12.13.2 | Reunion seguimiento |  | 0.12d | 2022-04-26 12:00 | 2022-04-26 13:00 | 199 | 2022-04-26 12:00 | 2022-04-26 13:00 | 0.12d | 30.62d | 0d | Gerentes de Procesos; Gerentes de Proyecto 1 | 2h | 812,320 | 812,320 |
| 201 | 1.12.13.3 | Cierre Contractual |  | 1d | 2022-04-26 15:00 | 2022-04-27 13:00 | 200 | 2022-04-26 15:00 | 2022-04-27 13:00 | 1d | 30.62d | 0d | Gerentes de Procesos [50%]; Gerentes de Proyecto 1 [50%] | 8h | 3,249,280 | 3,249,280 |
| 202 | 1.12.13.4 | Reunion seguimiento |  | 0.12d | 2022-04-27 15:00 | 2022-04-27 16:00 | 201 | 2022-04-27 15:00 | 2022-04-27 16:00 | 0.12d | 30.62d | 0d | Gerentes de Procesos; Gerentes de Proyecto 1 | 2h | 812,320 | 812,320 |
| 203 | 1.12.13.5 | Lecciones Aprendidas |  | 1d | 2022-04-27 16:00 | 2022-04-28 16:00 | 202 | 2022-04-27 16:00 | 2022-04-28 16:00 | 1d | 30.62d |  | Gerentes de Procesos [50%]; Gerentes de Proyecto 1 [50%] | 8h | 3,249,280 | 3,249,280 |
| 204 | 1.13 | FIN | milestone | 0d | 2022-06-10 11:00 | 2022-06-10 11:00 | 115, 203 | 2022-06-10 11:00 | 2022-06-10 11:00 | 0d | 0d |  |  |  |  |  |
